# DS001

Schedule from MS Project, 2009-11-16 to 2009-12-29, A marks actual dates.
Microsoft

## Calendars

- Standard: Mon-Fri 08:00-12:00, 13:00-17:00; Sat-Sun off.

## Resources

| Resource |
| --- |
| Dettmer, Tim |
| 61 |

## Schedule

| ID | WBS | Task | Type | Duration | Start | Finish | Predecessors | Complete | Remaining | Total slack | Arbeitspaket-ID | Text2 | Text3 |
| --- | --- | --- | --- | --- | --- | --- | --- | --- | --- | --- | --- | --- | --- |
| 1 | 1 | Planung |  | 1d? | 2009-11-16 | 2009-11-16 |  |  |  | 31d | A00 |  |  |
| 3 | 2 | Planung abgeschlossen | milestone | 0d | 2009-11-16 A | 2009-11-16 A |  | 100% |  |  | M00 |  |  |
| 4 | 3 | **Vorbereitung** |  | 7d? | 2009-11-16 A | 2009-11-24 | 3 | 94% | 0.41d? | 25d | A01 |  |  |
| 5 | 3.1 | **Aufstellungen** |  | 4d | 2009-11-16 A | 2009-11-19 A |  | 100% |  |  |  |  |  |
| 6 | 3.1.1 | Aufstellung alter Webseiten & Shop-Seiten |  | 1d | 2009-11-16 A | 2009-11-16 A |  | 100% |  |  | A0101 | ja |  |
| 7 | 3.1.2 | Priority Income-Urls: Backlinks |  | 1d | 2009-11-17 A | 2009-11-17 A | 6 | 100% |  |  | A0102 | ja |  |
| 8 | 3.1.3 | Priority Income-Urls: Social Signals |  | 1d | 2009-11-18 A | 2009-11-18 A | 7 | 100% |  |  | A0103 | ja |  |
| 9 | 3.1.4 | Priority Income-Urls: Traffic |  | 1d | 2009-11-19 A | 2009-11-19 A | 8 | 100% |  |  | A0104 | ja |  |
| 10 | 3.1.5 | SEA-, FB- & Retargeting-Urls |  | 1d | 2009-11-16 A | 2009-11-16 A |  | 100% |  |  | A0105 |  |  |
| 11 | 3.2 | **Redirects** |  | 3d | 2009-11-20 A | 2009-11-24 A | 6, 7, 8, 9, 10 | 100% |  |  |  |  |  |
| 12 | 3.2.1 | Erstellung einer Redirect-Übersicht |  | 1d | 2009-11-20 A | 2009-11-20 A |  | 100% |  |  | A0106 |  |  |
| 13 | 3.2.2 | Erstellung einer Old-Sitemap |  | 1d | 2009-11-23 A | 2009-11-23 A | 12 | 100% |  |  | A0107 |  |  |
| 14 | 3.2.3 | Erstellung Redirect-Datenbank |  | 1d | 2009-11-24 A | 2009-11-24 A | 13 | 100% |  |  | A0108 |  |  |
| 15 | 3.3 | **Content** |  | 4d | 2009-11-16 A | 2009-11-19 A |  | 100% |  |  |  |  |  |
| 16 | 3.3.1 | Content-Fertigstellung/Content-OPL |  | 1d | 2009-11-16 A | 2009-11-16 A |  | 100% |  |  | A0109 |  | interne Datei |
| 17 | 3.3.2 | Content zur VÖ freigeben |  | 1d | 2009-11-17 A | 2009-11-17 A | 16 | 100% |  |  | A0110 |  | interne Freigabe |
| 18 | 3.3.3 | OnPage-Analyse |  | 1d | 2009-11-18 A | 2009-11-18 A | 17 | 100% |  |  | A0111 |  |  |
| 19 | 3.3.4 | Bugfixes OnPage-Analyse |  | 1d | 2009-11-19 A | 2009-11-19 A | 18 | 100% |  |  | A0112 |  |  |
| 20 | 3.4 | **System-Test** |  | 1d? | 2009-11-20 A | 2009-11-20 | 19 | 67% | 0.33d? | 27d |  |  |  |
| 21 | 3.4.1 | Serp-Snippet-Test |  | 1d? | 2009-11-20 | 2009-11-20 |  |  |  | 27d | A0113 |  |  |
| 22 | 3.4.2 | FB- & Twitter/Social Meta-Tests & Debug |  | 1d | 2009-11-20 A | 2009-11-20 A |  | 100% |  |  | A0114 |  |  |
| 23 | 3.4.3 | Strukturierte Daten Test |  | 1d | 2009-11-20 A | 2009-11-20 A |  | 100% |  |  | A0115 |  |  |
| 24 | 3.5 | Umzugsdetailplan erstellen |  | 1d | 2009-11-16 A | 2009-11-16 A |  | 100% |  |  | A0116 |  |  |
| 25 | 3.6 | Testplan-Erstellung für Systemaudit nach Umzug |  | 1d | 2009-11-17 A | 2009-11-17 A | 24 | 100% |  |  | A0117 |  |  |
| 26 | 4 | Vorbereitung abgeschlossen | milestone | 0d | 2009-11-24 A | 2009-11-24 A | 4 | 100% |  |  | M01 |  |  |

| ID | WBS | Task | Type | Duration | Start | Finish | Predecessors | Complete | Arbeitspaket-ID | Text3 |
| --- | --- | --- | --- | --- | --- | --- | --- | --- | --- | --- |
| 27 | 5 | **Test-Umzug** |  | 7d | 2009-11-25 A | 2009-12-03 A | 26 | 100% | B01 |  |
| 28 | 5.1 | **Vorbereitung** |  | 2d | 2009-11-25 A | 2009-11-26 A |  | 100% |  |  |
| 29 | 5.1.1 | Klon-Erstellung bisherige Seite |  | 1d | 2009-11-25 A | 2009-11-25 A |  | 100% | B0101 |  |
| 30 | 5.1.2 | Besprechung der Durchführung des Umzugs anhand des Umzugsdetailplans |  | 1d | 2009-11-26 A | 2009-11-26 A | 29 | 100% | B0102 |  |
| 31 | 5.2 | **Durchführung** |  | 2d | 2009-11-27 A | 2009-11-30 A | 30 | 100% |  |  |
| 32 | 5.2.1 | Durchführung des Umzugs laut Umzugsdetailplan |  | 1d | 2009-11-27 A | 2009-11-27 A |  | 100% | B0103 |  |
| 33 | 5.2.2 | Festhalten der lessons learned (auch Confluence) |  | 1d | 2009-11-30 A | 2009-11-30 A | 32 | 100% | B0104 |  |
| 34 | 5.3 | **System-Test** |  | 2d | 2009-12-01 A | 2009-12-02 A | 31 | 100% |  |  |
| 35 | 5.3.1 | Durchführung Testbestellung |  | 1d | 2009-12-01 A | 2009-12-01 A |  | 100% | B0105 |  |
| 36 | 5.3.2 | Durchführung System-Audit für nach dem Umzug |  | 1d | 2009-12-01 A | 2009-12-01 A |  | 100% | B0106 |  |
| 37 | 5.3.3 | Festhalten der lessons learned |  | 1d | 2009-12-02 A | 2009-12-02 A | 35, 36 | 100% | B0107 |  |
| 38 | 5.4 | **Überarbeitung Best Practice Vorgehen** |  | 1d | 2009-12-03 A | 2009-12-03 A |  | 100% |  |  |
| 39 | 5.4.1 | Einarbeiten der Lessons Learned in den Umzugsdetailplan & Testplan |  | 1d | 2009-12-03 A | 2009-12-03 A | 37 | 100% | B0108 |  |
| 40 | 6 | Test-Umzug erfolgreich | milestone | 0d | 2009-12-03 A | 2009-12-03 A | 27 | 100% | M02 |  |
| 41 | 7 | **Live-Umzug** |  | 6d? | 2009-12-04 A | 2009-12-11 A | 40 | 100% | C01 |  |
| 42 | 7.1 | **Vorbereitung Go-Live** |  | 2d? | 2009-12-04 A | 2009-12-07 A |  | 100% |  |  |
| 43 | 7.1.1 | Erstellung einer PR-Aktion für die Dauer des Umzugs |  | 1d? | 2009-12-04 A | 2009-12-04 A |  | 100% | C0101 | nicht benötigt |
| 44 | 7.1.2 | Besprechung der Durchführung des Umzugs anhand des Umzugsdetailplans |  | 1d? | 2009-12-07 A | 2009-12-07 A | 43 | 100% | C0102 |  |
| 45 | 7.2 | **Go-Live** |  | 3d? | 2009-12-08 A | 2009-12-10 A | 42 | 100% |  |  |
| 46 | 7.2.1 | Offline + PR Landingpage |  | 1d? | 2009-12-08 A | 2009-12-08 A |  | 100% | C0103 | nicht benötigt |
| 47 | 7.2.2 | Durchführung des Umzugs laut Umzugsdetailplan |  | 1d? | 2009-12-09 A | 2009-12-09 A | 46 | 100% | C0104 |  |
| 48 | 7.2.3 | Umstellung der URLs von bezahlten Anzeigen |  | 1d? | 2009-12-10 A | 2009-12-10 A | 47 | 100% | C0105 |  |
| 49 | 7.3 | **System-Test** |  | 1d? | 2009-12-11 A | 2009-12-11 A | 45 | 100% |  |  |
| 50 | 7.3.1 | Durchführung Testbestellung |  | 1d? | 2009-12-11 A | 2009-12-11 A |  | 100% | C0106 |  |
| 51 | 7.3.2 | Durchführung System-Audit für nach dem Umzug |  | 1d? | 2009-12-11 A | 2009-12-11 A |  | 100% | C0107 |  |
| 52 | 8 | Live-Umzug durchgeführt | milestone | 0d | 2009-12-11 A | 2009-12-11 A | 41 | 100% | M03 |  |

| ID | WBS | Task | Type | Duration | Start | Finish | Predecessors | Complete | Remaining | Total slack | Free slack | Arbeitspaket-ID | Text3 |
| --- | --- | --- | --- | --- | --- | --- | --- | --- | --- | --- | --- | --- | --- |
| 53 | 9 | **After-Umzug-Check** |  | 6d? | 2009-12-14 A | 2009-12-21 | 52 | 33% | 4d? | 0d |  | D01 |  |
| 54 | 9.1 | Check der Darstellungen, mobile, etc. |  | 1d | 2009-12-14 | 2009-12-14 |  |  |  | 0.5d | 0d | D0101 |  |
| 55 | 9.2 | Liveschaltung der Webseite & Anzeigen/Ende PR-Aktion |  | 1d | 2009-12-15 A | 2009-12-15 | 54 | 50% | 0.5d | 0d |  | D0102 | nicht benötigt |
| 56 | 9.3 | **OnPage-Analyse** |  | 2d? | 2009-12-16 A | 2009-12-17 | 55 | 17% | 1.67d? | 0d |  | D02 |  |
| 57 | 9.3.1 | OnPage-Analyse durchführen |  | 1d? | 2009-12-16 A | 2009-12-16 |  | 50% | 0.5d? | 1d |  | D02 |  |
| 58 | 9.3.2 | Critical Major Bugs fixen |  | 1d | 2009-12-16 | 2009-12-16 |  |  |  | 0d |  | D0201 |  |
| 59 | 9.3.3 | OPL für Folgeprojekt OnPage-Optimierung |  | 1d | 2009-12-17 | 2009-12-17 | 58 |  |  | 0d |  | D0202 |  |
| 60 | 9.4 | **Nachbereitung Go-Live** |  | 2d | 2009-12-18 A | 2009-12-21 | 56 | 50% | 1d | 0d |  |  |  |
| 61 | 9.4.1 | Check der XML Sitemap + Einreichtung in WMT |  | 1d | 2009-12-18 A | 2009-12-18 A |  | 100% |  |  |  | D0301 |  |
| 62 | 9.4.2 | WMT "Abruf wie duch Google" |  | 1d | 2009-12-21 A | 2009-12-21 A | 61 | 100% |  |  |  | D0302 |  |
| 63 | 9.4.3 | Anpassen von Signaturen, E-Mail Templates, etc. |  | 1d | 2009-12-18 | 2009-12-18 |  |  |  | 1d |  | D0303 |  |
| 64 | 9.4.4 | Check der WMT, Analytics, Adserver & sonstiger Tracking-Codes |  | 1d | 2009-12-18 | 2009-12-18 |  |  |  | 1d |  | D0304 |  |
| 65 | 10 | Checks abgeschlossen | milestone | 0d | 2009-12-21 | 2009-12-21 | 56, 60 |  |  | 0d |  | M04 |  |
| 66 | 11 | Übernahme der Lessons Learned und des Umzuges in Confluence |  | 1d | 2009-12-22 | 2009-12-22 | 65 |  |  | 0d |  | D0401 |  |
| 67 | 12 | Umzug abgeschlossen | milestone | 0d | 2009-12-22 | 2009-12-22 | 66 |  |  | 0d |  | M05 |  |
| 68 | 13 | **Controlling** |  | 5d? | 2009-12-23 A | 2009-12-29 | 67 | 20% | 4d? | 0d |  | E01 |  |
| 69 | 13.1 | **Durchführung 1*Täglich** |  | 4d | 2009-12-23 A | 2009-12-28 |  | 20% | 3.2d | 0.2d |  |  |  |
| 70 | 13.1.1 | WMT: Crawling-Fehler |  | 1d | 2009-12-23 A | 2009-12-23 |  | 20% | 0.8d | 0.2d | 0d | E0101 |  |
| 71 | 13.1.2 | WMT: Indexstatus-Fehler; XML-Sitemap-Fehler |  | 1d | 2009-12-24 A | 2009-12-24 | 70 | 20% | 0.8d | 0.2d | 0d | E0102 |  |
| 72 | 13.1.3 | Analytics: Trafficverteilung, 404 o.ä. Traffic, Fehlertraffic |  | 1d | 2009-12-25 A | 2009-12-25 | 71 | 20% | 0.8d | 0.2d | 0d | E0103 |  |
| 73 | 13.1.4 | Xovi: Sichtbarkeitsüberwachung & KW-Monitoring |  | 1d | 2009-12-28 A | 2009-12-28 | 72 | 20% | 0.8d | 0.2d | 0d | E0104 |  |
